# integration_schedule

Schedule from MS Project, 2005-03-21 to 2005-05-02.
CERN

## Calendars

- Standard: Mon-Fri 08:00-12:00, 13:00-17:00; Sat-Sun off. Exceptions (off unless hours are given): 2005-03-25, 2005-03-28.

## Schedule

| ID | Task | Duration | Start | Finish | Predecessors | Total slack | Constraint |
| --- | --- | --- | --- | --- | --- | --- | --- |
| 1 | ITS rails | 6d | 2005-03-21 | 2005-03-30 |  | 0d | start no earlier than 2005-03-21 |
| 2 | Beampipe | 2d | 2005-03-31 | 2005-04-01 | 1 | 0d |  |
| 3 | V0/T0 | 3d | 2005-04-04 | 2005-04-06 | 2 | 0d |  |
| 4 | FMD3 | 1d | 2005-04-07 | 2005-04-07 | 3 | 0d |  |
| 5 | FMD3/beampipe | 1d | 2005-04-08 | 2005-04-08 | 4 | 0d |  |
| 6 | Pixel | 2d | 2005-04-11 | 2005-04-12 | 5 | 0d |  |
| 7 | ITS | 2d | 2005-04-13 | 2005-04-14 | 6 | 0d |  |
| 8 | FMD2 | 1d | 2005-04-15 | 2005-04-15 | 7 | 0d |  |
| 9 | FMD2/beampipe | 1d | 2005-04-18 | 2005-04-18 | 8 | 0d |  |
| 10 | Service chariot | 1d | 2005-04-19 | 2005-04-19 | 9 | 0d |  |
| 11 | Move TPC | 2d | 2005-04-20 | 2005-04-21 | 10 | 0d |  |
| 12 | Disengage ITS | 1d | 2005-04-22 | 2005-04-22 | 11 | 0d |  |
| 13 | Take out ITS rails | 1d | 2005-04-25 | 2005-04-25 | 12 | 0d |  |
| 14 | Reinstall ITS rails | 1d | 2005-04-26 | 2005-04-26 | 13 | 0d |  |
| 15 | Move TPC to parking | 1d | 2005-04-27 | 2005-04-27 | 14 | 0d |  |
| 16 | Uninstall | 3d | 2005-04-28 | 2005-05-02 | 15 | 0d |  |
