# integration_schedule

Schedule from MS Project, 2005-03-29 to 2005-05-12.
CERN

## Calendars

- Standard: Mon-Fri 08:00-12:00, 13:00-17:00; Sat-Sun off.

## Schedule

| ID | Task | Duration | Start | Finish | Predecessors | Total slack | Constraint |
| --- | --- | --- | --- | --- | --- | --- | --- |
| 1 | ITS rails | 6d | 2005-03-29 | 2005-04-05 |  | 0d | start no earlier than 2005-03-29 |
| 2 | Beampipe | 3d | 2005-04-06 | 2005-04-08 | 1 | 0d |  |
| 3 | V0/T0 | 3d | 2005-04-11 | 2005-04-13 | 2 | 0d |  |
| 4 | FMD3 | 1d | 2005-04-14 | 2005-04-14 | 3 | 0d |  |
| 5 | FMD3/beampipe | 1d | 2005-04-15 | 2005-04-15 | 4 | 0d |  |
| 6 | Pixel | 1d | 2005-04-18 | 2005-04-18 | 5 | 0d |  |
| 7 | ITS | 2d | 2005-04-19 | 2005-04-20 | 6 | 0d |  |
| 8 | Pixel | 1d | 2005-04-21 | 2005-04-21 | 7 | 0d |  |
| 9 | FMD2 | 1d | 2005-04-22 | 2005-04-22 | 8 | 0d |  |
| 10 | FMD2/beampipe | 1d | 2005-04-25 | 2005-04-25 | 9 | 0d |  |
| 11 | Service chariot | 1d | 2005-04-26 | 2005-04-26 | 10 | 0d |  |
| 12 | Move TPC | 2d | 2005-04-27 | 2005-04-28 | 11 | 0d |  |
| 13 | Disengage ITS | 1d | 2005-04-29 | 2005-04-29 | 12 | 0d |  |
| 14 | Take out ITS rails | 1d | 2005-05-02 | 2005-05-02 | 13 | 0d |  |
| 15 | Delphi Frame Load test | 3d | 2005-05-03 | 2005-05-05 | 14 | 0d |  |
| 16 | Reinstall ITS rails | 1d | 2005-05-06 | 2005-05-06 | 15 | 0d |  |
| 17 | Move TPC to parking | 1d | 2005-05-09 | 2005-05-09 | 16 | 0d |  |
| 18 | Uninstall | 3d | 2005-05-10 | 2005-05-12 | 17 | 0d |  |
