# integration_schedule

Schedule from MS Project, 2005-03-29 to 2005-05-06.
CERN

## Calendars

- Standard: Mon-Fri 08:00-12:00, 13:00-17:00; Sat-Sun off.

## Schedule

| ID | WBS | Task | Duration | Start | Finish | Predecessors | Total slack | Constraint |
| --- | --- | --- | --- | --- | --- | --- | --- | --- |
| 1 | 1 | **Integration Test** | 29d | 2005-03-29 | 2005-05-06 |  | 0d |  |
| 2 | 1.1 | ITS rails | 6d | 2005-03-29 | 2005-04-05 |  | 0d | start no earlier than 2005-03-29 |
| 3 | 1.2 | Beampipe | 3d | 2005-04-06 | 2005-04-08 | 2 | 0d |  |
| 4 | 1.3 | V0/T0 | 3d | 2005-04-11 | 2005-04-13 | 3 | 0d |  |
| 5 | 1.4 | FMD3 | 1d | 2005-04-14 | 2005-04-14 | 4 | 0d |  |
| 6 | 1.5 | FMD3/beampipe | 1d | 2005-04-15 | 2005-04-15 | 5 | 0d |  |
| 7 | 1.6 | Pixel | 1d | 2005-04-18 | 2005-04-18 | 6 | 0d |  |
| 8 | 1.7 | ITS (L) | 3d | 2005-04-19 | 2005-04-21 | 7 | 0d |  |
| 9 | 1.8 | Pixel | 1d | 2005-04-22 | 2005-04-22 | 8 | 0d |  |
| 10 | 1.9 | FMD2/beampipe | 1d | 2005-04-25 | 2005-04-25 | 9 | 0d |  |
| 11 | 1.10 | Service chariot (L)/Remove Scaffolding | 1d | 2005-04-26 | 2005-04-26 | 10 | 0d |  |
| 12 | 1.11 | Move TPC (L) | 2d | 2005-04-27 | 2005-04-28 | 11 | 0d |  |
| 13 | 1.12 | Disengage ITS, Fix valve | 1d | 2005-04-29 | 2005-04-29 | 12 | 0d |  |
| 14 | 1.13 | Take out ITS rails, Reinstall | 1d | 2005-05-02 | 2005-05-02 | 13 | 0d |  |
| 15 | 1.14 | Move TPC to parking | 1d | 2005-05-03 | 2005-05-03 | 14 | 0d |  |
| 16 | 1.15 | Install scaffolding | 1d | 2005-05-04 | 2005-05-04 | 15 | 0d |  |
| 17 | 1.16 | Uninstall | 2d | 2005-05-05 | 2005-05-06 | 16 | 0d |  |
